# Villa project single floor

Schedule from Primavera P6, 2020-10-26 to 2021-01-15, data date 2020-10-26, costs in PKR.

## Calendars

- Corporate - Standard Full Time: Mon-Fri 08:00-16:00; Sat-Sun off.

## Resources

| Resource | Group | Rate |
| --- | --- | --- |
| Labour | labor | 100 |
| Mason | labor | 150 |
| Steel Fixer | labor |  |
| Carpenter | labor |  |
| Window and Door Fixer | labor |  |
| Painter | labor |  |

## Schedule

| ID | WBS | Activity | Type | Duration | Start | Finish | Predecessors | Total float | Resources | Cost |
| --- | --- | --- | --- | --- | --- | --- | --- | --- | --- | --- |
|  | 1 | **Preliminary Works** |  |  | 2020-10-26 | 2020-10-30 |  |  |  |  |
| A1000 |  | Project Start | milestone | 0d | 2020-10-26 | 2020-10-26 |  | 0d |  |  |
| A1010 |  | Intiial Prepatory works |  | 5d | 2020-10-26 | 2020-10-30 | A1000 | 0d |  |  |
|  | 2 | **Sub Structural Works** |  |  | 2020-11-02 | 2020-11-06 |  |  |  |  |
| A1020 |  | Excavation |  | 1d | 2020-11-02 | 2020-11-02 | A1010 | 0d | Labour [80 h] | 8,000 |
| A1030 |  | Foundation Masonary |  | 3.87d | 2020-11-03 | 2020-11-06 | A1020 | 0d | Mason [152 h]; Labour [232 h] | 46,000 |
|  | 3 | **Super Strutural Works** |  |  | 2020-11-06 | 2021-01-14 |  |  |  |  |
|  | 1 | **Structural Works** |  |  | 2020-11-06 | 2020-12-04 |  |  |  |  |
| A1040 |  | Plinth Beam |  | 1d | 2020-11-06 | 2020-11-09 | A1030 | 0d | Mason [8 h]; Labour [48 h] | 6,000 |
| A1050 |  | Block Work Masonary in Super Structure |  | 6.75d | 2020-11-09 | 2020-11-18 | A1040 | 0d | Mason [144 h]; Labour [216 h] | 43,200 |
| A1060 |  | Column Steel Work |  | 1d | 2020-11-18 | 2020-11-19 | A1050 | 0d | Steel Fixer [24 h] |  |
| A1070 |  | Column Form Work |  | 1d | 2020-11-18 | 2020-11-19 | A1060 FF | 0d | Carpenter [24 h] |  |
| A1080 |  | Column Concrete Work |  | 1d | 2020-11-19 | 2020-11-20 | A1070 | 0d | Mason [8 h]; Labour [48 h] | 6,000 |
| A1090 |  | Slab and Beam Form Work |  | 6d | 2020-11-20 | 2020-11-30 | A1080 | 0d | Carpenter [144 h] |  |
| A1100 |  | Slab and Beam Steal Work |  | 2.67d | 2020-11-30 | 2020-12-03 | A1090 | 0d | Steel Fixer [64 h] |  |
| A1110 |  | Slab and Concrete Work |  | 1d | 2020-12-03 | 2020-12-04 | A1100 | 0d | Mason [16 h]; Labour [96 h] | 12,000 |
|  | 2 | **Architectural Works** |  |  | 2020-12-25 | 2021-01-14 |  |  |  |  |
| A1120 |  | Plaster Work |  | 8.33d | 2020-12-25 | 2021-01-06 | A1110 FS+15d | 0d | Mason [400 h]; Labour [400 h] | 100,000 |
| A1130 |  | Flooring Work |  | 1d | 2021-01-06 | 2021-01-07 | A1120 | 0d | Mason [16 h]; Labour [96 h] | 12,000 |
| A1140 |  | Window and Door Fixing |  | 1d | 2021-01-07 | 2021-01-08 | A1130 | 0d | Window and Door Fixer [80 h] |  |
| A1150 |  | Paint Work |  | 4.33d | 2021-01-08 | 2021-01-14 | A1140 | 0d | Painter [208 h] |  |
|  | 4 | **Final Commisioning work** |  |  | 2021-01-14 | 2021-01-15 |  |  |  |  |
| A1160 |  | Final Check List |  | 1d | 2021-01-14 | 2021-01-15 | A1150 | 0d |  |  |
|  | 5 | **Project Close Out** |  |  | 2021-01-15 | 2021-01-15 |  |  |  |  |
| A1170 |  | Project Hand Over | milestone | 0d | 2021-01-15 | 2021-01-15 | A1160 | 0d |  |  |
